# hydArray

Schedule from MS Project, 2008-01-21 to 2008-11-06, costs in $.
MBARI

## Calendars

- Standard: Mon-Fri 08:00-12:00, 13:00-17:00; Sat-Sun off.

## Resources

| Resource | Rate |
| --- | --- |
| $ | 1 |
| Gene Massion |  |
| Gene M. |  |
| Elec Tech |  |
| Elec Eng |  |

## Schedule

| ID | WBS | Task | Duration | Start | Finish | Predecessors | Total slack | Free slack | Resources | Work | Cost |
| --- | --- | --- | --- | --- | --- | --- | --- | --- | --- | --- | --- |
| 1 | 1 | **Acoustic Sediment Tracking System** | 209d? | 2008-01-21 | 2008-11-06 |  | 0d |  |  | 600h | 38,420 |
| 2 | 1.1 | **System Engineering** | 209d? | 2008-01-21 | 2008-11-06 |  | 0d |  |  | 104h |  |
| 3 | 1.1.1 | Review lit, refine req'ts review concept | 3d? | 2008-01-21 | 2008-01-23 |  | 206d |  | Gene M. | 24h |  |
| 4 | 1.1.2 | Experiment Design and deployment plan | 2d? | 2008-01-21 | 2008-01-22 |  | 207d |  | Gene M. | 16h |  |
| 5 | 1.1.3 | EE Consulting | 5d | 2008-01-21 | 2008-01-25 |  | 204d |  | Elec Eng | 40h |  |
| 6 | 1.1.4 | Final report/publication | 3d | 2008-11-04 | 2008-11-06 | 49FS+20d | 0d |  | Gene M. | 24h |  |
| 7 | 1.2 | **Project Management** | 5d? | 2008-01-21 | 2008-01-25 |  | 204d |  |  | 56h |  |
| 8 | 1.2.1 | Meetings, minutes, etc | 5d? | 2008-01-21 | 2008-01-25 |  | 204d |  | Gene M. | 40h |  |
| 9 | 1.2.2 | Purchasing | 2d? | 2008-01-21 | 2008-01-22 |  | 207d |  | Gene M. | 16h |  |
| 10 | 1.3 | **Receiver** | 40d? | 2008-01-21 | 2008-03-14 |  | 0d |  |  | 232h | 22,170 |
| 11 | 1.3.1 | **Preliminary design** | 16d? | 2008-01-21 | 2008-02-11 |  | 0d |  |  | 128h |  |
| 12 | 1.3.1.1 | Modify pressure housing | 3d? | 2008-01-21 | 2008-01-23 |  | 0d |  | Gene M. | 24h |  |
| 13 | 1.3.1.2 | Write Labview data logger VI | 5d? | 2008-01-24 | 2008-01-30 | 12 | 0d |  | Gene M. | 40h |  |
| 14 | 1.3.1.3 | battery connect circuit | 5d | 2008-01-31 | 2008-02-06 | 13 | 0d |  | Elec Tech | 40h |  |
| 15 | 1.3.1.4 | Bench test | 3d | 2008-02-07 | 2008-02-11 | 14 | 0d |  | Gene M. | 24h |  |
| 16 | 1.3.2 | **Final design** | 3d? | 2008-02-27 | 2008-02-29 | 31 | 1d | 0d |  | 24h |  |
| 17 | 1.3.2.1 | Implement Design Changes | 3d? | 2008-02-27 | 2008-02-29 |  | 1d |  | Gene M. | 24h |  |
| 18 | 1.3.3 | Build, Integrate, Test | 10d | 2008-03-03 | 2008-03-14 | 16 | 19d |  | Gene M. | 80h |  |
| 19 | 1.3.4 | **Materials** | 1d? | 2008-02-12 | 2008-02-12 | 11 | 42d |  |  |  | 22,170 |
| 20 | 1.3.4.1 | DAQ hardware | 1d | 2008-02-12 | 2008-02-12 |  | 42d |  | $ [550000%] |  | 5,500 |
| 21 | 1.3.4.2 | USB Drive | 1d | 2008-02-12 | 2008-02-12 |  | 42d |  | $ [52000%] |  | 520 |
| 22 | 1.3.4.3 | end cap | 1d? | 2008-02-12 | 2008-02-12 |  | 42d |  | $ [25000%] |  | 250 |
| 23 | 1.3.4.4 | cable, connectors | 1d? | 2008-02-12 | 2008-02-12 |  | 42d |  | $ [125000%] |  | 1,250 |
| 24 | 1.3.4.5 | battery interconnect CCA | 1d? | 2008-02-12 | 2008-02-12 |  | 42d |  | $ [25000%] |  | 250 |
| 25 | 1.3.4.6 | deployment frame | 1d | 2008-02-12 | 2008-02-12 |  | 42d |  | $ [100000%] |  | 1,000 |
| 26 | 1.3.4.7 | Short duration battery pack | 1d? | 2008-02-12 | 2008-02-12 |  | 42d |  | $ [40000%] |  | 400 |
| 27 | 1.3.4.8 | Long duration battery pack | 1d? | 2008-02-12 | 2008-02-12 |  | 42d |  | $ [650000%] |  | 6,500 |
| 28 | 1.3.4.9 | On shore storage costs | 1d | 2008-02-12 | 2008-02-12 |  | 42d |  | $ [500000%] |  | 5,000 |
| 29 | 1.3.4.10 | General supplies | 1d | 2008-02-12 | 2008-02-12 |  | 42d |  | $ [150000%] |  | 1,500 |

| ID | WBS | Task | Duration | Start | Finish | Predecessors | Total slack | Free slack | Resources | Work | Cost |
| --- | --- | --- | --- | --- | --- | --- | --- | --- | --- | --- | --- |
| 30 | 1.4 | **Source** | 22d? | 2008-02-12 | 2008-03-12 |  | 0d |  |  | 152h | 16,250 |
| 31 | 1.4.1 | **Preliminary design** | 11d? | 2008-02-12 | 2008-02-26 | 11 | 0d |  |  | 88h |  |
| 32 | 1.4.1.1 | Modify pressure housing | 3d? | 2008-02-12 | 2008-02-14 |  | 0d |  | Gene M. | 24h |  |
| 33 | 1.4.1.2 | Write Labview data logger VI | 5d? | 2008-02-15 | 2008-02-21 | 32 | 0d |  | Gene M. | 40h |  |
| 34 | 1.4.1.3 | Bench test | 3d? | 2008-02-22 | 2008-02-26 | 33 | 0d |  | Gene M. | 24h |  |
| 35 | 1.4.2 | **Final design** | 3d? | 2008-03-03 | 2008-03-05 | 16 | 1d | 0d |  | 24h |  |
| 36 | 1.4.2.1 | Implement Design Changes | 3d? | 2008-03-03 | 2008-03-05 |  | 1d |  | Gene M. | 24h |  |
| 37 | 1.4.3 | Build, Integrate, Test | 5d? | 2008-03-06 | 2008-03-12 | 35 | 1d |  | Gene M. | 40h |  |
| 38 | 1.4.4 | **Materials** | 1d? | 2008-02-27 | 2008-02-27 | 31 | 11d |  |  |  | 16,250 |
| 39 | 1.4.4.1 | Edgetech source | 1d? | 2008-02-27 | 2008-02-27 |  | 11d |  | $ |  | 11,950 |
| 40 | 1.4.4.2 | DAQ hardware | 1d | 2008-02-27 | 2008-02-27 |  | 11d |  | $ [55000%] |  | 550 |
| 41 | 1.4.4.3 | cable, connectors | 1d? | 2008-02-27 | 2008-02-27 |  | 11d |  | $ [125000%] |  | 1,250 |
| 42 | 1.4.4.4 | mounting frame | 1d | 2008-02-27 | 2008-02-27 |  | 11d |  | $ [100000%] |  | 1,000 |
| 43 | 1.4.4.5 | General supplies | 1d | 2008-02-27 | 2008-02-27 |  | 11d |  | $ [150000%] |  | 1,500 |
| 44 | 1.5 | PDR | 1d | 2008-02-27 | 2008-02-27 | 11, 31 | 0d |  |  |  |  |
| 45 | 1.6 | CDR | 1d | 2008-03-27 | 2008-03-27 | 16, 35, 44FS+20d | 0d |  |  |  |  |
| 46 | 1.7 | **Deployments** | 127d | 2008-04-11 | 2008-10-06 |  | 0d |  |  | 56h |  |
| 47 | 1.7.1 | First test deployment | 3d | 2008-04-11 | 2008-04-15 | 30FS+20d, 10, 45FS+10d | 0d |  | Gene M. | 24h |  |
| 48 | 1.7.2 | Second test deployment | 3d | 2008-05-28 | 2008-05-30 | 47FS+30d | 0d |  | Gene M. | 24h |  |
| 49 | 1.7.3 | Recovery dive | 1d | 2008-10-06 | 2008-10-06 | 48FS+90d | 0d |  | Gene M. | 8h |  |
